# Program Kerja Fasa Pra-Pembinaan PAP (Tanpa Pindaan)

Schedule from MS Project, 2018-01-01 to 2018-07-17.
Unit Amalan Terbaik, BPPK, CPAB

## Calendars

- Standard: Mon-Fri 08:00-12:00, 13:00-17:00; Sat-Sun off.

## Schedule

| ID | WBS | Task | Type | Duration | Start | Finish | Predecessors | Total slack |
| --- | --- | --- | --- | --- | --- | --- | --- | --- |
| 1 | 1 | **Program Kerja Fasa Pra-Pembinaan Reka dan Bina** |  | 142d | 2018-01-01 | 2018-07-17 |  | 0d |
| 2 | 1.1 | Mula Pembinaan | milestone | 0d | 2018-01-01 | 2018-01-01 |  | 0d |
| 3 | 1.2 | **Perancangan Pelaksanaan Projek** |  | 62d | 2018-01-01 | 2018-03-27 |  | 0d |
| 4 | 1.2.1 | Rancang Strategi Pelaksanaan |  | 1d | 2018-01-01 | 2018-01-01 | 2 | 0d |
| 5 | 1.2.2 | Terima Arahan Pelaksanaan dan Brif Projek |  | 3d | 2018-01-02 | 2018-01-04 | 4 | 0d |
| 6 | 1.2.3 | Lantik HOPT |  | 1d | 2018-01-05 | 2018-01-05 | 5 | 0d |
| 7 | 1.2.4 | Laksana ACAT |  | 1d | 2018-01-08 | 2018-01-08 | 6 | 0d |
| 8 | 1.2.5 | Lantik HODT |  | 1d | 2018-01-09 | 2018-01-09 | 7 | 0d |
| 9 | 1.2.6 | Laksana GN1 |  | 1d | 2018-01-10 | 2018-01-10 | 8 | 0d |
| 10 | 1.2.7 | Laksana Semakan Brif 01-1, Verifikasi Harta Pelanggan dan Analisis Sumber Manusia |  | 3d | 2018-01-11 | 2018-01-15 | 9 | 0d |
| 11 | 1.2.8 | Sedia Rekabentuk Konsep dan Dokumen Tender |  | 30d | 2018-01-16 | 2018-02-26 | 10 | 0d |
| 12 | 1.2.9 | Sedia Kos Anggaran Awalan |  | 3d | 2018-02-27 | 2018-03-01 | 11 | 0d |
| 13 | 1.2.10 | Sedia Pelan Kualiti / RMP |  | 3d | 2018-02-27 | 2018-03-01 | 11 | 16d |
| 14 | 1.2.11 | Kajian Semula Rekabentuk Konsep |  | 3d | 2018-02-27 | 2018-03-01 | 11 | 0d |
| 15 | 1.2.12 | Laksana VE |  | 5d | 2018-03-02 | 2018-03-08 | 12, 14 | 0d |
| 16 | 1.2.13 | Pengesahan Brif Projek, Rekabentuk Konsep dan Kos Awalan |  | 1d | 2018-03-23 | 2018-03-23 | 15FS+10d | 0d |
| 17 | 1.2.14 | Pendaftaran Maklumat dalam SKALA |  | 1d | 2018-03-26 | 2018-03-26 | 13, 16 | 0d |
| 18 | 1.2.15 | Laksana GN3 |  | 1d | 2018-03-27 | 2018-03-27 | 17 | 0d |
| 19 | 1.2.16 | Siap Perancangan | milestone | 0d | 2018-03-27 | 2018-03-27 | 18 | 0d |
| 20 | 1.3 | **Perolehan** |  | 80d | 2018-03-28 | 2018-07-17 |  | 0d |
| 21 | 1.3.1 | Sedia Dokumen Tawaran |  | 10d | 2018-03-28 | 2018-04-10 | 19 | 0d |
| 22 | 1.3.2 | Tawaran / Iklan |  | 20d | 2018-04-11 | 2018-05-08 | 21 | 0d |
| 23 | 1.3.3 | Penilaian Tawaran |  | 15d | 2018-05-09 | 2018-05-29 | 22 | 0d |
| 24 | 1.3.4 | Lembaga Tender |  | 10d | 2018-05-30 | 2018-06-12 | 23 | 0d |
| 25 | 1.3.5 | ATDA & Sah Peruntukan |  | 10d | 2018-06-13 | 2018-06-26 | 24 | 0d |
| 26 | 1.3.6 | Mengemukakan dan Penerimaan NCR Terhadap Cadangan Tender |  | 10d | 2018-06-27 | 2018-07-10 | 25 | 0d |
| 27 | 1.3.7 | Surat Setuju Terima Tender |  | 5d | 2018-07-11 | 2018-07-17 | 26 | 0d |
| 28 | 1.4 | Tamat Pra-Pembinaan | milestone | 0d | 2018-07-17 | 2018-07-17 | 27 | 0d |
